Schedule from MS Project, 2025-07-02 to 2025-12-24, status date 2025-05-05, 10 hours a day.
Microsoft

## Calendars

- Стандартный: Mon-Sun 09:00-13:00, 14:00-18:00.

## Resources

| Resource | Group |
| --- | --- |
| Стропольщик 1 | Бригада 1 |
| Сварщик 1 | Бригада 1 |
| Монтажник 1 | Бригада 1 |
| Подсобник 1 | Бригада 1 |
| Стропольщик 2 | Бригада 2 |
| Сварщик 2 | Бригада 2 |
| Монтажник 2 | Бригада 2 |
| Подсобник 2 | Бригада 2 |
| Кран ДЭК-251 |  |
| Кран ДЭК-321 |  |
| Манипулятор |  |
| Пиканиска коленчатая |  |
| Геодезист |  |

## Schedule

| ID | WBS | Task | Type | Duration | Start | Finish | Predecessors | Total slack | Free slack | Constraint | Resources | Work | Text10 | ЕИ |
| --- | --- | --- | --- | --- | --- | --- | --- | --- | --- | --- | --- | --- | --- | --- |
| 1 | 1 | **Конвейерная галерея №3** |  | 140.1d | 2025-07-02 | 2025-12-24 |  | 0d |  |  |  | 32694.3h |  |  |
| 2 | 1.1 | **Захватка 1 (ось 1-9)** |  | 35.1d | 2025-07-02 | 2025-08-14 |  | 1.3d |  |  |  | 4989.02h |  |  |
| 3 | 1.1.1 | Поставка материалов | milestone | 0d | 2025-07-02 | 2025-07-02 |  | 1.3d | 0d | start no earlier than 2025-07-02 |  |  |  |  |
| 4 | 1.1.2 | **Колонны** |  | 6.4d | 2025-07-02 | 2025-07-09 |  | 1.3d |  |  |  | 692h |  |  |
| 5 | 1.1.2.1 | Монтаж колонн одноэтажных и многоэтажных зданий и крановых эстакад высотой: до 25 м составного сечения массой до 5,0 т |  | 7d | 2025-07-02 | 2025-07-09 | 3 | 1.3d | 0d |  | Стропольщик 1 [200%]; Монтажник 1 [200%]; Кран ДЭК-251; Кран ДЭК-321; Манипулятор; Стропольщик 2 [200%]; Монтажник 2 [200%]; Подсобник 2; Сварщик 2; Геодезист [0%]; Пиканиска коленчатая | 692h |  |  |
| 6 | 1.1.3 | **Балки перекрытий и фермы ФП1** |  | 12.8d | 2025-07-07 | 2025-07-23 |  | 1.3d |  |  |  | 836.44h |  |  |
| 7 | 1.1.3.1 | Монтаж балок, ригелей перекрытия, покрытия и под установку оборудования многоэтажных зданий при высоте здания: до 25 м |  | 12d | 2025-07-07 | 2025-07-23 | 5FS-2d | 1.3d | 0d |  | Стропольщик 1 [300%]; Монтажник 1 [300%]; Подсобник 1 [200%]; Сварщик 1 [150%]; Кран ДЭК-251; Кран ДЭК-321; Манипулятор; Стропольщик 2 [300%]; Монтажник 2 | 836.44h |  |  |
| 8 | 1.1.4 | **Связи горизонт. и вертик.** |  | 8d | 2025-07-13 | 2025-07-23 |  | 0.9d |  |  |  | 737.68h |  |  |
| 9 | 1.1.4.1 | Монтаж связей и распорок из одиночных и парных уголков, гнутосварных профилей для пролетов: до 24 м при высоте здания до 25 м |  | 7.56d | 2025-07-13 | 2025-07-23 | 7FS-8d | 0.9d | 0d |  | Стропольщик 1 [200%]; Монтажник 1 [400%]; Сварщик 1 [150%]; Монтажник 2 [250%]; Кран ДЭК-251; Кран ДЭК-321; Манипулятор; Стропольщик 2 [200%]; Подсобник 2 [200%]; Пиканиска коленчатая | 737.68h |  |  |
| 10 | 1.1.5 | **Стеновой фахверк** |  | 7.1d | 2025-07-22 | 2025-07-31 |  | 0.9d |  |  |  | 246.62h |  |  |
| 11 | 1.1.5.1 | Монтаж фахверка |  | 5.7d | 2025-07-22 | 2025-07-31 | 9FS-1d | 0.9d | 0d |  | Стропольщик 1; Монтажник 1; Подсобник 1 [200%]; Сварщик 1; Кран ДЭК-251; Кран ДЭК-321; Манипулятор; Монтажник 2; Стропольщик 2; Подсобник 2 | 246.62h |  |  |
| 12 | 1.1.6 | **Прогоны покрытия** |  | 6.7d | 2025-07-23 | 2025-07-31 |  | 105.73d |  |  |  | 276.49h |  |  |
| 13 | 1.1.6.1 | Монтаж балок, ригелей перекрытия, покрытия и под установку оборудования многоэтажных зданий при высоте здания: до 25 м |  | 6d | 2025-07-23 | 2025-07-31 | 7 | 105.73d | 0d |  | Стропольщик 1; Монтажник 1 [250%]; Подсобник 1 [300%]; Сварщик 1; Кран ДЭК-321; Манипулятор; Стропольщик 2 [200%]; Монтажник 2 [300%] | 276.49h |  |  |
| 14 | 1.1.7 | **Лестницы,площадки,огражден. и щиты** |  | 10.01d | 2025-07-23 | 2025-08-05 |  | 112.89d |  |  |  | 253.37h |  |  |
| 15 | 1.1.7.1 | Монтаж лестниц прямолинейных и криволинейных, пожарных с ограждением |  | 7.01d | 2025-07-23 | 2025-08-05 | 7 | 112.89d |  |  | Монтажник 1 [150%]; Подсобник 1 [300%]; Сварщик 1 [200%]; Кран ДЭК-321; Манипулятор; Стропольщик 2 [200%]; Монтажник 2 [350%] | 253.37h |  |  |
| 16 | 1.1.8 | **Настил** |  | 17.9d | 2025-07-23 | 2025-08-14 |  | 105d |  |  |  | 1706.43h |  |  |
| 17 | 1.1.8.1 | Монтаж площадок с настилом и ограждением из листовой, рифленой, просечной и круглой стали |  | 13.37d | 2025-07-23 | 2025-08-12 | 7 | 107.13d |  |  | Сварщик 1 [200%]; Монтажник 1 [400%]; Подсобник 1 [200%]; Стропольщик 2 [200%]; Кран ДЭК-321; Манипулятор | 904.07h |  |  |
| 18 | 1.1.8.2 | Монтаж кровельного покрытия: из профилированного листа при высоте здания до 25 м |  | 9.37d | 2025-07-31 | 2025-08-13 | 13 | 105.73d |  |  | Монтажник 1 [400%]; Стропольщик 1 [200%]; Подсобник 1 [200%]; Кран ДЭК-321; Манипулятор | 416.48h |  |  |
| 19 | 1.1.8.3 | Монтаж ограждающих конструкций стен: из профилированного листа при высоте здания до 30 м (10% на подрезку) |  | 10.6d | 2025-07-31 | 2025-08-14 | 11 | 105d |  |  | Монтажник 1 [400%]; Подсобник 1 [200%]; Кран ДЭК-321; Манипулятор | 385.88h | по КМ монтаж изнутри, уточнить |  |
| 20 | 1.1.9 | **Опоры под оборудование ЗД1-ЗД3** |  | 1.8d | 2025-07-23 | 2025-07-25 |  | 121.1d |  |  |  | 100h |  |  |
| 21 | 1.1.9.1 | Монтаж металлоконструкций постаментов под технологическое оборудование |  | 2d | 2025-07-23 | 2025-07-25 | 7 | 121.1d |  |  | Сварщик 1 [200%]; Подсобник 1; Монтажник 1 [200%]; Геодезист [0.1%] | 100h |  |  |
| 22 | 1.1.10 | **Антикоррозионная обработка** |  | 6.3d | 2025-07-31 | 2025-08-07 |  | 0.8d |  |  |  | 140h |  |  |
| 23 | 1.1.10.1 | Огрунтовка металлических поверхностей за один раз: грунтовкой ГФ-021 |  | 3d | 2025-07-31 | 2025-08-03 | 11 | 0.9d | 0d |  | Подсобник 1 [200%] | 60h |  | м2 |
| 24 | 1.1.10.2 | Окраска металлических огрунтованных поверхностей: эмалью ПФ-115 (за 2 раза) К=2 |  | 4d | 2025-08-03 | 2025-08-07 | 23 | 0.8d | 0d |  | Подсобник 1 [200%] | 80h |  | м2 |

| ID | WBS | Task | Duration | Start | Finish | Predecessors | Total slack | Free slack | Resources | Work | ЕИ |
| --- | --- | --- | --- | --- | --- | --- | --- | --- | --- | --- | --- |
| 25 | 1.2 | **Захватка 2 (ось 10-17)** | 33.79d | 2025-08-08 | 2025-09-19 |  | 0.8d |  |  | 7612.76h |  |
| 26 | 1.2.1 | **Колонны** | 8d | 2025-08-08 | 2025-08-17 |  | 0.8d |  |  | 954h |  |
| 27 | 1.2.1.1 | Монтаж колонн одноэтажных и многоэтажных зданий и крановых эстакад высотой: до 25 м составного сечения массой до 5,0 т | 7d | 2025-08-08 | 2025-08-17 | 24 | 0.8d | 0d | Стропольщик 1 [200%]; Кран ДЭК-251; Кран ДЭК-321; Манипулятор; Стропольщик 2 [200%]; Монтажник 2 [200%]; Подсобник 2 [200%]; Сварщик 2; Геодезист [0.1%]; Пиканиска коленчатая; Монтажник 1 [200%] | 954h |  |
| 28 | 1.2.2 | **Балки перекрытий и фермы ФП1** | 11.8d | 2025-08-14 | 2025-08-28 |  | 0.8d |  |  | 1698h |  |
| 29 | 1.2.2.1 | Монтаж балок, ригелей перекрытия, покрытия и под установку оборудования многоэтажных зданий при высоте здания: до 25 м | 13d | 2025-08-14 | 2025-08-28 | 27FS-3d | 0.8d | 0d | Стропольщик 1 [300%]; Монтажник 1 [300%]; Подсобник 1 [200%]; Сварщик 1 [150%]; Кран ДЭК-251; Кран ДЭК-321; Манипулятор; Стропольщик 2 [300%]; Монтажник 2 | 1698h |  |
| 30 | 1.2.3 | **Связи горизонт. и вертик.** | 8.19d | 2025-08-19 | 2025-08-29 |  | 1.75d |  |  | 938.68h |  |
| 31 | 1.2.3.1 | Монтаж связей и распорок из одиночных и парных уголков, гнутосварных профилей для пролетов: до 24 м при высоте здания до 25 м | 8.39d | 2025-08-19 | 2025-08-29 | 29FS-8d | 1.75d | 0d | Стропольщик 1 [200%]; Монтажник 1 [400%]; Сварщик 1 [150%]; Монтажник 2 [250%]; Кран ДЭК-251; Кран ДЭК-321; Манипулятор; Стропольщик 2 [200%]; Подсобник 2 [200%]; Пиканиска коленчатая | 938.68h |  |
| 32 | 1.2.4 | **Стеновой фахверк** | 6.2d | 2025-08-27 | 2025-09-04 |  | 3.35d |  |  | 418h |  |
| 33 | 1.2.4.1 | Монтаж фахверка | 6.7d | 2025-08-27 | 2025-09-04 | 31FS-1d | 3.35d | 0d | Монтажник 1; Подсобник 1 [200%]; Сварщик 1; Кран ДЭК-251; Кран ДЭК-321; Манипулятор; Монтажник 2; Стропольщик 2; Подсобник 2; Стропольщик 1 | 418h |  |
| 34 | 1.2.5 | **Прогоны покрытия** | 5.3d | 2025-09-04 | 2025-09-11 |  | 76.71d |  |  | 360h |  |
| 35 | 1.2.5.1 | Монтаж балок, ригелей перекрытия, покрытия и под установку оборудования многоэтажных зданий при высоте здания: до 25 м | 6d | 2025-09-04 | 2025-09-11 | 33 | 76.71d | 0d | Стропольщик 1; Монтажник 1 [250%]; Подсобник 1 [300%]; Сварщик 1; Кран ДЭК-321; Манипулятор; Стропольщик 2 [200%]; Монтажник 2 [300%] | 360h |  |
| 36 | 1.2.6 | **Лестницы,площадки,огражден. и щиты** | 5d | 2025-08-29 | 2025-09-04 |  | 88.7d |  |  | 428.08h |  |
| 37 | 1.2.6.1 | Монтаж лестниц прямолинейных и криволинейных, пожарных с ограждением | 5.4d | 2025-08-29 | 2025-09-04 | 29 | 88.7d |  | Монтажник 1 [150%]; Подсобник 1 [300%]; Сварщик 1 [200%]; Кран ДЭК-321; Манипулятор; Стропольщик 2 [200%]; Монтажник 2 [350%] | 428.08h |  |
| 38 | 1.2.7 | **Настил** | 16.99d | 2025-08-29 | 2025-09-19 |  | 76.71d |  |  | 2576h |  |
| 39 | 1.2.7.1 | Монтаж площадок с настилом и ограждением из листовой, рифленой, просечной и круглой стали | 12.1d | 2025-08-29 | 2025-09-11 | 29 | 83d |  | Сварщик 1 [200%]; Монтажник 1 [400%]; Подсобник 1 [200%]; Стропольщик 2 [200%]; Кран ДЭК-321; Манипулятор | 1350h |  |
| 40 | 1.2.7.2 | Монтаж кровельного покрытия: из профилированного листа при высоте здания до 25 м | 6.99d | 2025-09-11 | 2025-09-19 | 35 | 76.71d |  | Монтажник 1 [400%]; Стропольщик 1 [200%]; Подсобник 1 [200%]; Кран ДЭК-321; Манипулятор | 574h |  |
| 41 | 1.2.7.3 | Монтаж ограждающих конструкций стен: из профилированного листа при высоте здания до 30 м (10% на подрезку) | 9.59d | 2025-09-04 | 2025-09-15 | 33 | 79.51d |  | Монтажник 1 [400%]; Подсобник 1 [200%]; Кран ДЭК-321; Манипулятор | 652h |  |
| 42 | 1.2.8 | **Опоры под оборудование ЗД1-ЗД3** | 1.8d | 2025-08-29 | 2025-08-31 |  | 91.9d |  |  | 100h |  |
| 43 | 1.2.8.1 | Монтаж металлоконструкций постаментов под технологическое оборудование | 2d | 2025-08-29 | 2025-08-31 | 29 | 91.9d |  | Сварщик 1 [200%]; Подсобник 1; Монтажник 1 [200%]; Геодезист [0.1%] | 100h |  |
| 44 | 1.2.9 | **Антикоррозионная обработка** | 6.2d | 2025-09-04 | 2025-09-12 |  | 3.35d |  |  | 140h |  |
| 45 | 1.2.9.1 | Огрунтовка металлических поверхностей за один раз: грунтовкой ГФ-021 | 3d | 2025-09-04 | 2025-09-08 | 33 | 3.34d | 0d | Подсобник 1 [200%] | 60h | м2 |
| 46 | 1.2.9.2 | Окраска металлических огрунтованных поверхностей: эмалью ПФ-115 (за 2 раза) К=2 | 4d | 2025-09-08 | 2025-09-12 | 45 | 3.34d | 0d | Подсобник 1 [200%] | 80h | м2 |
| 47 | 1.3 | **Захватка 3 (ось 18-25)** | 36.9d | 2025-09-12 | 2025-10-28 |  | 3.35d |  |  | 6955.29h |  |
| 48 | 1.3.1 | **Колонны** | 10.6d | 2025-09-12 | 2025-09-25 |  | 3.35d |  |  | 749.29h |  |
| 49 | 1.3.1.1 | Монтаж колонн одноэтажных и многоэтажных зданий и крановых эстакад высотой: до 25 м составного сечения массой до 5,0 т | 6.03d | 2025-09-12 | 2025-09-25 | 46 | 3.35d | 0d | Стропольщик 1 [200%]; Монтажник 1 [200%]; Кран ДЭК-251; Кран ДЭК-321; Манипулятор; Стропольщик 2 [200%]; Монтажник 2 [200%]; Подсобник 2; Сварщик 2; Геодезист [0.1%]; Пиканиска коленчатая | 749.29h |  |

| ID | WBS | Task | Duration | Start | Finish | Predecessors | Total slack | Free slack | Resources | Work | Text10 | ЕИ |
| --- | --- | --- | --- | --- | --- | --- | --- | --- | --- | --- | --- | --- |
| 50 | 1.3.2 | **Балки перекрытий и фермы ФП1** | 10.6d | 2025-09-21 | 2025-10-05 |  | 3.35d |  |  | 1804h |  |  |
| 51 | 1.3.2.1 | Монтаж балок, ригелей перекрытия, покрытия и под установку оборудования многоэтажных зданий при высоте здания: до 25 м | 12d | 2025-09-21 | 2025-10-05 | 49FS-3d | 3.35d | 0d | Стропольщик 1 [300%]; Монтажник 1 [300%]; Подсобник 1 [200%]; Сварщик 1 [150%]; Кран ДЭК-251; Кран ДЭК-321; Манипулятор; Стропольщик 2 [300%]; Монтажник 2 | 1804h |  |  |
| 52 | 1.3.3 | **Связи горизонт. и вертик.** | 8.9d | 2025-09-25 | 2025-10-06 |  | 2.15d |  |  | 923h |  |  |
| 53 | 1.3.3.1 | Монтаж связей и распорок из одиночных и парных уголков, гнутосварных профилей для пролетов: до 24 м при высоте здания до 25 м | 7.9d | 2025-09-25 | 2025-10-06 | 51FS-8d | 2.15d | 0d | Стропольщик 1 [200%]; Монтажник 1 [400%]; Сварщик 1 [150%]; Монтажник 2 [250%]; Кран ДЭК-251; Кран ДЭК-321; Манипулятор; Стропольщик 2 [200%]; Подсобник 2 [200%]; Пиканиска коленчатая | 923h |  |  |
| 54 | 1.3.4 | **Стеновой фахверк** | 5.4d | 2025-10-05 | 2025-10-11 |  | 2.04d |  |  | 300h |  |  |
| 55 | 1.3.4.1 | Монтаж фахверка | 6d | 2025-10-05 | 2025-10-11 | 53FS-1d | 2.04d | 0d | Стропольщик 1; Монтажник 1; Подсобник 1 [200%]; Сварщик 1; Кран ДЭК-251; Кран ДЭК-321; Манипулятор; Монтажник 2; Стропольщик 2; Подсобник 2 | 300h |  |  |
| 56 | 1.3.5 | **Прогоны покрытия** | 4.4d | 2025-10-11 | 2025-10-17 |  | 45.11d |  |  | 350h |  |  |
| 57 | 1.3.5.1 | Монтаж балок, ригелей перекрытия, покрытия и под установку оборудования многоэтажных зданий при высоте здания: до 25 м | 5d | 2025-10-11 | 2025-10-17 | 55 | 45.11d | 0d | Стропольщик 1; Монтажник 1 [250%]; Подсобник 1 [300%]; Сварщик 1; Кран ДЭК-321; Манипулятор; Стропольщик 2 [200%]; Монтажник 2 [300%] | 350h |  |  |
| 58 | 1.3.6 | **Лестницы,площадки,огражден. и щиты** | 4.61d | 2025-10-05 | 2025-10-10 |  | 58.31d |  |  | 335h |  |  |
| 59 | 1.3.6.1 | Монтаж лестниц прямолинейных и криволинейных, пожарных с ограждением | 4.91d | 2025-10-05 | 2025-10-10 | 51 | 58.31d |  | Монтажник 1 [150%]; Подсобник 1 [300%]; Сварщик 1 [200%]; Кран ДЭК-321; Манипулятор; Стропольщик 2 [200%]; Монтажник 2 [350%] | 335h | есть лестница? |  |
| 60 | 1.3.7 | **Настил** | 18.7d | 2025-10-05 | 2025-10-28 |  | 45.21d |  |  | 2254h |  |  |
| 61 | 1.3.7.1 | Монтаж площадок с настилом и ограждением из листовой, рифленой, просечной и круглой стали | 12d | 2025-10-05 | 2025-10-18 | 51 | 52.71d |  | Сварщик 1 [200%]; Монтажник 1 [400%]; Подсобник 1 [200%]; Стропольщик 2 [200%]; Кран ДЭК-321; Манипулятор | 1360h |  |  |
| 62 | 1.3.7.2 | Монтаж кровельного покрытия: из профилированного листа при высоте здания до 25 м | 7.9d | 2025-10-17 | 2025-10-28 | 57 | 45.21d |  | Монтажник 1 [400%]; Стропольщик 1 [200%]; Подсобник 1 [200%]; Кран ДЭК-321; Манипулятор | 516h |  |  |
| 63 | 1.3.7.3 | Монтаж ограждающих конструкций стен: из профилированного листа при высоте здания до 30 м (10% на подрезку) | 8.31d | 2025-10-11 | 2025-10-23 | 55 | 48.51d |  | Монтажник 1 [400%]; Подсобник 1 [200%]; Кран ДЭК-321; Манипулятор | 378h |  |  |
| 64 | 1.3.8 | **Опоры под оборудование ЗД1-ЗД3** | 1.8d | 2025-10-05 | 2025-10-07 |  | 62.11d |  |  | 100h |  |  |
| 65 | 1.3.8.1 | Монтаж металлоконструкций постаментов под технологическое оборудование | 2d | 2025-10-05 | 2025-10-07 | 51 | 62.11d |  | Сварщик 1 [200%]; Подсобник 1; Монтажник 1 [200%]; Геодезист [0.1%] | 100h |  |  |
| 66 | 1.3.9 | **Антикоррозионная обработка** | 6.2d | 2025-10-11 | 2025-10-19 |  | 2.04d |  |  | 140h |  |  |
| 67 | 1.3.9.1 | Огрунтовка металлических поверхностей за один раз: грунтовкой ГФ-021 | 3d | 2025-10-11 | 2025-10-15 | 55 | 2.04d | 0d | Подсобник 1 [200%] | 60h |  | м2 |
| 68 | 1.3.9.2 | Окраска металлических огрунтованных поверхностей: эмалью ПФ-115 (за 2 раза) К=2 | 4d | 2025-10-15 | 2025-10-19 | 67 | 2.04d | 0d | Подсобник 1 [200%] | 80h |  | м2 |
| 69 | 1.4 | **Захватка 4 (ось 26-33)** | 30.21d | 2025-10-19 | 2025-11-26 |  | 2.04d |  |  | 6535.26h |  |  |
| 70 | 1.4.1 | **Колонны** | 6.36d | 2025-10-19 | 2025-10-27 |  | 1.79d |  |  | 434.54h |  |  |
| 71 | 1.4.1.1 | Монтаж колонн одноэтажных и многоэтажных зданий и крановых эстакад высотой: до 25 м составного сечения массой до 5,0 т | 5.06d | 2025-10-19 | 2025-10-27 | 68 | 1.79d | 0d | Стропольщик 1 [200%]; Монтажник 1 [200%]; Кран ДЭК-251; Кран ДЭК-321; Манипулятор; Стропольщик 2 [200%]; Монтажник 2 [200%]; Подсобник 2; Сварщик 2; Геодезист [0.1%]; Пиканиска коленчатая | 434.54h |  |  |
| 72 | 1.4.2 | **Балки перекрытий и фермы ФП1** | 10.9d | 2025-10-25 | 2025-11-07 |  | 1.05d |  |  | 1532.63h |  |  |
| 73 | 1.4.2.1 | Монтаж балок, ригелей перекрытия, покрытия и под установку оборудования многоэтажных зданий при высоте здания: до 25 м | 12d | 2025-10-25 | 2025-11-07 | 71FS-2d | 1.05d | 0d | Стропольщик 1 [300%]; Монтажник 1 [300%]; Подсобник 1 [200%]; Сварщик 1 [150%]; Кран ДЭК-251; Кран ДЭК-321; Манипулятор; Стропольщик 2 [300%]; Монтажник 2 | 1532.63h |  |  |

| ID | WBS | Task | Duration | Start | Finish | Predecessors | Total slack | Free slack | Resources | Work | ЕИ |
| --- | --- | --- | --- | --- | --- | --- | --- | --- | --- | --- | --- |
| 74 | 1.4.3 | **Связи горизонт. и вертик.** | 6.2d | 2025-10-29 | 2025-11-06 |  | 1.05d |  |  | 899h |  |
| 75 | 1.4.3.1 | Монтаж связей и распорок из одиночных и парных уголков, гнутосварных профилей для пролетов: до 24 м при высоте здания до 25 м | 7d | 2025-10-29 | 2025-11-06 | 73FS-7d | 1.05d | 0d | Стропольщик 1 [200%]; Монтажник 1 [400%]; Сварщик 1 [150%]; Монтажник 2 [250%]; Кран ДЭК-251; Кран ДЭК-321; Манипулятор; Стропольщик 2 [200%]; Подсобник 2 [200%]; Пиканиска коленчатая | 899h |  |
| 76 | 1.4.4 | **Стеновой фахверк** | 3.6d | 2025-11-05 | 2025-11-09 |  | 1.45d |  |  | 260h |  |
| 77 | 1.4.4.1 | Монтаж фахверка | 4d | 2025-11-05 | 2025-11-09 | 75FS-1d | 1.45d | 0d | Стропольщик 1; Монтажник 1; Подсобник 1 [200%]; Сварщик 1; Кран ДЭК-251; Кран ДЭК-321; Манипулятор; Монтажник 2; Стропольщик 2; Подсобник 2 | 260h |  |
| 78 | 1.4.5 | **Прогоны покрытия** | 4.4d | 2025-11-09 | 2025-11-15 |  | 21.75d |  |  | 350h |  |
| 79 | 1.4.5.1 | Монтаж балок, ригелей перекрытия, покрытия и под установку оборудования многоэтажных зданий при высоте здания: до 25 м | 5d | 2025-11-09 | 2025-11-15 | 77 | 21.75d | 0d | Стропольщик 1; Монтажник 1 [250%]; Подсобник 1 [300%]; Сварщик 1; Кран ДЭК-321; Манипулятор; Стропольщик 2 [200%]; Монтажник 2 [300%] | 350h |  |
| 80 | 1.4.6 | **Лестницы,площадки,огражден. и щиты** | 5.3d | 2025-11-07 | 2025-11-14 |  | 31.85d |  |  | 660h |  |
| 81 | 1.4.6.1 | Монтаж лестниц прямолинейных и криволинейных, пожарных с ограждением | 6d | 2025-11-07 | 2025-11-14 | 73 | 31.85d |  | Стропольщик 1 [200%]; Монтажник 1 [400%]; Подсобник 1 [300%]; Сварщик 1 [200%] | 660h |  |
| 82 | 1.4.7 | **Настил** | 14.95d | 2025-11-07 | 2025-11-26 |  | 22.2d |  |  | 2159.09h |  |
| 83 | 1.4.7.1 | Монтаж площадок с настилом и ограждением из листовой, рифленой, просечной и круглой стали | 12d | 2025-11-07 | 2025-11-21 | 73 | 26.35d |  | Сварщик 1 [200%]; Монтажник 1 [400%]; Подсобник 1 [200%]; Стропольщик 2 [200%]; Кран ДЭК-321; Манипулятор | 1252h |  |
| 84 | 1.4.7.2 | Монтаж кровельного покрытия: из профилированного листа при высоте здания до 25 м | 7.7d | 2025-11-15 | 2025-11-26 | 79 | 21.85d |  | Монтажник 1 [400%]; Стропольщик 1 [200%]; Подсобник 1 [200%]; Кран ДЭК-321; Манипулятор | 518h |  |
| 85 | 1.4.7.3 | Монтаж ограждающих конструкций стен: из профилированного листа при высоте здания до 30 м (10% на подрезку) | 8d | 2025-11-09 | 2025-11-21 | 77 | 24.69d |  | Монтажник 1 [400%]; Подсобник 1 [200%]; Кран ДЭК-321; Манипулятор | 389.09h |  |
| 86 | 1.4.8 | **Опоры под оборудование ЗД1-ЗД3** | 1.8d | 2025-11-07 | 2025-11-09 |  | 35.35d |  |  | 100h |  |
| 87 | 1.4.8.1 | Монтаж металлоконструкций постаментов под технологическое оборудование | 2d | 2025-11-07 | 2025-11-09 | 73 | 35.35d |  | Сварщик 1 [200%]; Подсобник 1; Монтажник 1 [200%]; Геодезист [0.1%] | 100h |  |
| 88 | 1.4.9 | **Антикоррозионная обработка** | 6.2d | 2025-11-09 | 2025-11-17 |  | 1.45d |  |  | 140h |  |
| 89 | 1.4.9.1 | Огрунтовка металлических поверхностей за один раз: грунтовкой ГФ-021 | 3d | 2025-11-09 | 2025-11-13 | 77 | 1.45d | 0d | Подсобник 1 [200%] | 60h | м2 |
| 90 | 1.4.9.2 | Окраска металлических огрунтованных поверхностей: эмалью ПФ-115 (за 2 раза) К=2 | 4d | 2025-11-13 | 2025-11-17 | 89 | 1.45d | 0d | Подсобник 1 [200%] | 80h | м2 |
| 91 | 1.5 | **Захватка 5 (ось 34-41)** | 29.15d | 2025-11-17 | 2025-12-24 |  | 0d |  |  | 6602h |  |
| 92 | 1.5.1 | **Колонны** | 5.6d | 2025-11-17 | 2025-11-24 |  | 1.45d |  |  | 430h |  |
| 93 | 1.5.1.1 | Монтаж колонн одноэтажных и многоэтажных зданий и крановых эстакад высотой: до 25 м составного сечения массой до 5,0 т | 4.35d | 2025-11-17 | 2025-11-24 | 90 | 1.45d | 0d | Стропольщик 1 [200%]; Монтажник 1 [200%]; Кран ДЭК-251; Кран ДЭК-321; Манипулятор; Стропольщик 2 [200%]; Монтажник 2 [200%]; Подсобник 2; Сварщик 2; Геодезист [0.1%]; Пиканиска коленчатая | 430h |  |
| 94 | 1.5.2 | **Балки перекрытий и фермы ФП1** | 10.55d | 2025-11-22 | 2025-12-05 |  | 0d |  |  | 1265h |  |
| 95 | 1.5.2.1 | Монтаж балок, ригелей перекрытия, покрытия и под установку оборудования многоэтажных зданий при высоте здания: до 25 м | 11.45d | 2025-11-22 | 2025-12-05 | 93FS-2d | 0d |  | Стропольщик 1 [300%]; Монтажник 1 [300%]; Подсобник 1 [200%]; Сварщик 1 [150%]; Кран ДЭК-251; Кран ДЭК-321; Манипулятор; Стропольщик 2 [300%]; Монтажник 2 | 1265h |  |
| 96 | 1.5.3 | **Связи горизонт. и вертик.** | 7.1d | 2025-11-25 | 2025-12-04 |  | 0d |  |  | 955h |  |
| 97 | 1.5.3.1 | Монтаж связей и распорок из одиночных и парных уголков, гнутосварных профилей для пролетов: до 24 м при высоте здания до 25 м | 8d | 2025-11-25 | 2025-12-04 | 95FS-8d | 0d |  | Стропольщик 1 [200%]; Монтажник 1 [400%]; Сварщик 1 [150%]; Монтажник 2 [250%]; Кран ДЭК-251; Кран ДЭК-321; Манипулятор; Стропольщик 2 [200%]; Подсобник 2 [200%]; Пиканиска коленчатая | 955h |  |

| ID | WBS | Task | Duration | Start | Finish | Predecessors | Total slack | Free slack | Resources | Work | ЕИ |
| --- | --- | --- | --- | --- | --- | --- | --- | --- | --- | --- | --- |
| 98 | 1.5.4 | **Стеновой фахверк** | 5.4d | 2025-12-03 | 2025-12-09 |  | 0d |  |  | 210h |  |
| 99 | 1.5.4.1 | Монтаж фахверка | 6d | 2025-12-03 | 2025-12-09 | 97FS-1d | 0d |  | Стропольщик 1; Монтажник 1; Подсобник 1 [200%]; Сварщик 1; Кран ДЭК-251; Кран ДЭК-321; Манипулятор; Монтажник 2; Стропольщик 2; Подсобник 2 | 210h |  |
| 100 | 1.5.5 | **Прогоны покрытия** | 4.4d | 2025-12-09 | 2025-12-15 |  | 0d |  |  | 350h |  |
| 101 | 1.5.5.1 | Монтаж балок, ригелей перекрытия, покрытия и под установку оборудования многоэтажных зданий при высоте здания: до 25 м | 5d | 2025-12-09 | 2025-12-15 | 99 | 0d |  | Стропольщик 1; Монтажник 1 [250%]; Подсобник 1 [300%]; Сварщик 1; Кран ДЭК-321; Манипулятор; Стропольщик 2 [200%]; Монтажник 2 [300%] | 350h |  |
| 102 | 1.5.6 | **Лестницы,площадки,огражден. и щиты** | 5.3d | 2025-12-05 | 2025-12-12 |  | 9.7d |  |  | 740h |  |
| 103 | 1.5.6.1 | Монтаж лестниц прямолинейных и криволинейных, пожарных с ограждением | 6d | 2025-12-05 | 2025-12-12 | 95 | 9.7d |  | Монтажник 1 [150%]; Подсобник 1 [300%]; Сварщик 1 [200%]; Кран ДЭК-321; Манипулятор; Стропольщик 2 [200%]; Монтажник 2 [350%] | 740h |  |
| 104 | 1.5.7 | **Настил** | 15d | 2025-12-05 | 2025-12-24 |  | 0d |  |  | 2412h |  |
| 105 | 1.5.7.1 | Монтаж площадок с настилом и ограждением из листовой, рифленой, просечной и круглой стали | 12d | 2025-12-05 | 2025-12-18 | 95 | 4.3d |  | Сварщик 1 [200%]; Монтажник 1 [400%]; Подсобник 1 [200%]; Стропольщик 2 [200%]; Кран ДЭК-321; Манипулятор | 1312h |  |
| 106 | 1.5.7.2 | Монтаж кровельного покрытия: из профилированного листа при высоте здания до 25 м | 8d | 2025-12-15 | 2025-12-24 | 101 | 0d |  | Монтажник 1 [400%]; Стропольщик 1 [200%]; Подсобник 1 [200%]; Кран ДЭК-321; Манипулятор | 722h |  |
| 107 | 1.5.7.3 | Монтаж ограждающих конструкций стен: из профилированного листа при высоте здания до 30 м (10% на подрезку) | 8.3d | 2025-12-09 | 2025-12-22 | 99 | 1.4d |  | Монтажник 1 [400%]; Подсобник 1 [200%]; Кран ДЭК-321; Манипулятор | 378h |  |
| 108 | 1.5.8 | **Опоры под оборудование ЗД1-ЗД3** | 1.8d | 2025-12-05 | 2025-12-07 |  | 13.2d |  |  | 100h |  |
| 109 | 1.5.8.1 | Монтаж металлоконструкций постаментов под технологическое оборудование | 2d | 2025-12-05 | 2025-12-07 | 95 | 13.2d |  | Сварщик 1 [200%]; Подсобник 1; Монтажник 1 [200%]; Геодезист [0.1%] | 100h |  |
| 110 | 1.5.9 | **Антикоррозионная обработка** | 6.2d | 2025-12-09 | 2025-12-17 |  | 5.3d |  |  | 140h |  |
| 111 | 1.5.9.1 | Огрунтовка металлических поверхностей за один раз: грунтовкой ГФ-021 | 3d | 2025-12-09 | 2025-12-13 | 99 | 5.3d | 0d | Подсобник 1 [200%] | 60h | м2 |
| 112 | 1.5.9.2 | Окраска металлических огрунтованных поверхностей: эмалью ПФ-115 (за 2 раза) К=2 | 4d | 2025-12-13 | 2025-12-17 | 111 | 5.3d |  | Подсобник 1 [200%] | 80h | м2 |
